# samsample 1 steel building

Schedule from MS Project, 2011-07-19 to 2012-02-07, costs in $, A marks actual dates.
H

## Calendars

- Standard: Mon-Fri 08:00-12:00, 13:00-17:00; Sat-Sun off.

## Resources

| Resource | Rate |
| --- | --- |
| Survey Crew | 110 |
| Excavation Team w/equip | 500 |
| Fine Excav Team | 750 |
| Iron Workers | 200 |
| Laborers - Crew 1 | 80 |
| Laborers - Crew 2 | 80 |
| Laborers - Crew 3 | 80 |
| Roofers | 200 |
| Concrete Team | 500 |
| Plumbers | 200 |
| HVAC | 200 |
| Power Team | 200 |
| Communications | 200 |

## Schedule

| ID | WBS | Task | Type | Duration | Start | Finish | Predecessors | Remaining | Total slack | Work | Cost |
| --- | --- | --- | --- | --- | --- | --- | --- | --- | --- | --- | --- |
| 1 | 1 | Notice to Proceed | milestone | 1d | 2011-07-19 A | 2011-07-19 |  | 1d | 0d |  |  |
| 2 | 2 | Order Marble Counter Tops |  | 135d | 2011-07-20 A | 2012-01-31 | 1 | 135d | 0d |  |  |
| 3 | 3 | Site Survey |  | 1d | 2011-07-20 A | 2011-07-20 | 1 | 1d | 0d | 8h | 880 |
| 4 | 4 | Clear and Grub |  | 2d | 2011-07-21 A | 2011-07-22 | 3 | 2d | 0d | 16h | 8,000 |
| 5 | 5 | Excavation |  | 6d | 2011-07-25 A | 2011-08-01 | 4 | 6d | 0d | 48h | 24,000 |
| 6 | 6 | Drainage Systems |  | 5d | 2011-08-02 A | 2011-08-08 | 5 | 5d | 69d | 40h | 30,000 |
| 7 | 7 | Building Layout |  | 2d | 2011-08-02 A | 2011-08-03 | 5 | 2d | 0d | 16h | 1,760 |
| 8 | 8 | **Foundations** |  | 16d | 2011-08-04 A | 2011-08-25 |  | 16d | 0d | 144h | 41,280 |
| 9 | 8.1 | Layout |  | 1d | 2011-08-04 A | 2011-08-04 | 7 | 1d | 0d | 8h | 880 |
| 10 | 8.2 | Fine Excavation |  | 3d | 2011-08-05 A | 2011-08-09 | 9 | 3d | 0d | 24h | 18,000 |
| 11 | 8.3 | Rebar |  | 5d | 2011-08-10 A | 2011-08-16 | 10 | 5d | 0d | 40h | 8,000 |
| 12 | 8.4 | Anchor Bolts |  | 2d | 2011-08-10 A | 2011-08-11 | 10 | 2d | 8d | 16h | 3,200 |
| 13 | 8.5 | Forms |  | 5d | 2011-08-17 A | 2011-08-23 | 11 | 5d | 0d | 40h | 3,200 |
| 14 | 8.6 | Concrete |  | 2d | 2011-08-24 A | 2011-08-25 | 12, 13 | 2d | 0d | 16h | 8,000 |
| 15 | 9 | **Structure** |  | 50d | 2011-08-26 A | 2011-11-03 |  | 50d | 0d | 400h | 80,000 |
| 16 | 9.1 | Frame Exterior Walls |  | 25d | 2011-08-26 A | 2011-09-29 | 14 | 25d | 0d | 200h | 40,000 |
| 17 | 9.2 | Frame Roof |  | 10d | 2011-09-30 A | 2011-10-13 | 16 | 10d | 0d | 80h | 16,000 |
| 18 | 9.3 | Frame Interior Walls |  | 15d | 2011-10-14 A | 2011-11-03 | 17 | 15d | 0d | 120h | 24,000 |
| 19 | 10 | Exterior Wall Finishes |  | 30d | 2011-09-30 A | 2011-11-10 | 16 | 30d | 0d | 240h | 19,200 |
| 20 | 11 | Roof |  | 10d | 2011-10-14 A | 2011-10-27 | 17 | 10d | 5d | 80h | 16,000 |
| 21 | 12 | Install Doors and Windows |  | 10d | 2011-09-30 A | 2011-10-13 | 16 | 10d | 15d | 80h | 6,400 |
| 22 | 13 | **Interior Finishes** |  | 68d | 2011-11-04 A | 2012-02-07 |  | 68d | 0d | 160h | 12,800 |
| 23 | 13.1 | Rock Interior Walls |  | 5d | 2011-11-04 A | 2011-11-10 | 18, 21, 20 | 5d | 0d | 40h | 3,200 |
| 24 | 13.2 | Install Counters |  | 10d | 2011-11-11 A | 2011-11-24 | 23 | 10d | 48d | 80h | 6,400 |
| 25 | 13.3 | Install Counter Tops |  | 5d | 2012-02-01 A | 2012-02-07 | 2, 24 | 5d | 0d | 40h | 3,200 |

| ID | WBS | Task | Type | Duration | Start | Finish | Predecessors | Remaining | Total slack | Work | Cost |
| --- | --- | --- | --- | --- | --- | --- | --- | --- | --- | --- | --- |
| 26 | 14 | **Mechanical** |  | 45d | 2011-10-14 A | 2011-12-15 |  | 45d | 0d | 480h | 96,000 |
| 27 | 14.1 | Plumbing |  | 30d | 2011-11-04 A | 2011-12-15 | 18 | 30d | 38d | 240h | 48,000 |
| 28 | 14.2 | HVAC |  | 30d | 2011-10-14 A | 2011-11-24 | 17 | 30d | 53d | 240h | 48,000 |
| 29 | 15 | **Electrical** |  | 60d | 2011-11-04 A | 2012-01-26 |  | 60d | 0d | 480h | 96,000 |
| 30 | 15.1 | Power |  | 40d | 2011-11-04 A | 2011-12-29 | 18 | 40d | 0d | 320h | 64,000 |
| 31 | 15.2 | Communications |  | 20d | 2011-12-30 A | 2012-01-26 | 30 | 20d | 8d | 160h | 32,000 |
| 32 | 16 | Finish Site Work |  | 55d | 2011-11-11 A | 2012-01-26 | 6, 19 | 55d | 8d | 440h | 35,200 |
| 33 | 17 | Project Completion | milestone | 1d | 2012-02-07 A | 2012-02-07 | 32, 28, 27, 25, 31 | 1d | 0d |  |  |
